# Lançamento Comercial de produto

Schedule from MS Project, 2006-11-13 to 2006-12-29, status date 2007-05-28.
Objetivo didático
CIn-UFPE
Projeto de exemplo para fixação do / treinamento

## Calendars

- Produção: Mon-Sat 09:00-13:00, 14:00-18:00; Sun off.
- Reuniões: Mon-Fri 09:00-13:00, 14:00-19:00; Sat-Sun off.

## Schedule

| ID | WBS | Task | Type | Duration | Start | Finish | Predecessors | Total slack | Free slack | Constraint | Deadline | Calendar | Text1 |
| --- | --- | --- | --- | --- | --- | --- | --- | --- | --- | --- | --- | --- | --- |
| 1 | 1 | **Lançamento Comercial de produto** |  | 40.25d | 2006-11-13 | 2006-12-29 |  | 0d |  |  |  |  |  |
| 2 | 1.1 | **Rotinas da Administração** |  | 40.25d | 2006-11-13 | 2006-12-29 |  | 0d |  |  |  |  |  |
| 3 | 1.1.1 | Comunicar Metas |  | 4h | 2006-11-13 | 2006-11-13 |  | 0d |  |  |  |  | TI |
| 4 | 1.1.2 | Providenciar Registro |  | 4d | 2006-11-13 | 2006-11-17 | 3 | 29.75d | 5.75d |  |  |  | TI |
| 5 | 1.1.3 | Contatar Veículo Propaganda |  | 3d | 2006-11-13 | 2006-11-16 | 3 | 27.75d | 0d |  |  |  | TI |
| 6 | 1.1.4 | Comprar Material de Propaganda |  | 3d | 2006-11-13 | 2006-11-16 | 3 | 27.75d | 0d |  |  |  | TI |
| 7 | 1.1.5 | Discutir Vendas |  | 3d | 2006-11-16 | 2006-11-21 | 5, 6 | 25.12d | 3.12d |  | 2007-05-28 | Reuniões | TI |
| 8 | 1.1.6 | Reavaliar Processos |  | 4h | 2006-11-24 | 2006-11-24 | 4, 7, 25 | 24d | 0d |  |  |  | TI |
| 9 | 1.1.7 | Discutir Lançamento |  | 12h | 2006-11-24 | 2006-11-27 | 8 | 21.62d |  |  |  | Reuniões | TI |
| 10 | 1.1.8 | Conferir material propaganda |  | 6h | 2006-11-16 | 2006-11-17 | 6 | 30d | 0d |  |  |  | TI |
| 11 | 1.1.9 | Distribuir material propaganda |  | 2d | 2006-11-17 | 2006-11-20 | 10 | 30d |  |  |  |  | TI |
| 12 | 1.1.10 | Veicular comercial |  | 3d | 2006-12-21 | 2006-12-25 | 5 | 0d |  | as late as possible |  |  | TI |
| 13 | 1.1.11 | Lançar Produto |  | 4d | 2006-12-25 | 2006-12-29 | 9, 11, 12, 21 | 0d |  |  |  |  | TI |
| 14 | 1.2 | **Rotinas de Produção** |  | 35.75d | 2006-11-13 | 2006-12-25 |  | 0d |  |  |  |  |  |
| 15 | 1.2.1 | Produzir Protótipo |  | 5d | 2006-11-13 | 2006-11-18 | 3 | 0d |  |  |  |  | TI |
| 16 | 1.2.2 | Produzir Produto |  | 14d | 2006-11-22 | 2006-12-08 | 24 | 0d |  |  |  |  | TI |
| 17 | 1.2.3 | Produzir Embalagem |  | 4d | 2006-12-08 | 2006-12-13 | 16 | 0d |  |  |  |  | II |
| 18 | 1.2.4 | Pronto para Embalar | milestone | 0d | 2006-12-13 | 2006-12-13 | 16, 17 | 0d |  |  |  |  | TI |
| 19 | 1.2.5 | Embalar |  | 6d | 2006-12-13 | 2006-12-20 | 18 | 0d |  |  |  |  | TI |
| 20 | 1.2.6 | Carregar |  | 2d | 2006-12-20 | 2006-12-22 | 19 | 0d |  |  |  |  | TI |
| 21 | 1.2.7 | Distribuir |  | 2d | 2006-12-22 | 2006-12-25 | 20 | 0d |  |  |  |  | TI |
| 22 | 1.2.8 | **Teste de Qualidade** |  | 4.75d | 2006-11-18 | 2006-11-24 |  | 0d |  |  |  |  |  |
| 23 | 1.2.8.1 | Colher/testar Amostra |  | 6h | 2006-11-18 | 2006-11-20 | 15 | 0d |  |  |  |  | TI |
| 24 | 1.2.8.2 | Analisar Resultados |  | 2d | 2006-11-20 | 2006-11-22 | 23 | 0d |  |  |  |  | TI |
| 25 | 1.2.8.3 | Redigir Relatório Técnico |  | 2d | 2006-11-22 | 2006-11-24 | 24 | 24d | 0d |  |  |  | TI |
